# CSP transformation roadmap plan v03

Schedule from MS Project, 2009-07-01 to 2013-11-29, status date 2009-06-07.
Gov3

## Calendars

- Standard: Mon-Fri 08:00-12:00, 13:00-17:00; Sat-Sun off.

## Schedule

| ID | WBS | Task | Type | Duration | Start | Finish | Predecessors | Total slack | Free slack | Constraint |
| --- | --- | --- | --- | --- | --- | --- | --- | --- | --- | --- |
| 1 | 1 | **Planning** |  | 128d | 2009-07-01 | 2009-12-25 |  | 1025d |  |  |
| 2 | 1.1 | **Project inception** |  | 25d | 2009-07-01 | 2009-08-04 |  | 1128d |  |  |
| 3 | 1.1.1 | Establish project team - people, roles, logistics |  | 10d | 2009-07-01 | 2009-07-14 |  | 379d | 0d |  |
| 4 | 1.1.2 | Identify key stakeholders |  | 5d | 2009-07-06 | 2009-07-10 |  | 395d | 10d | start no earlier than 2009-07-06 |
| 5 | 1.1.3 | Project kick-off session | milestone | 1d | 2009-07-15 | 2009-07-15 | 3 | 393d |  |  |
| 6 | 1.1.4 | Develop PID - objs, plans, processes |  | 15d | 2009-07-15 | 2009-08-04 | 3 | 379d |  |  |
| 7 | 1.1.5 | Initial stakeholder communications | milestone | 1d | 2009-07-27 | 2009-07-27 | 4 | 385d |  | start no earlier than 2009-07-27 |
| 8 | 1.2 | **Business drivers analysis** |  | 18d | 2009-08-05 | 2009-08-28 |  | 1110d |  |  |
| 9 | 1.2.1 | Internal project team input - prep, workshop & write up |  | 8d | 2009-08-05 | 2009-08-14 |  | 371d |  | start no earlier than 2009-08-05 |
| 10 | 1.2.2 | Stakeholder team input - prep, workshop(s) & write up |  | 10d | 2009-08-17 | 2009-08-28 |  | 361d |  | start no earlier than 2009-08-17 |
| 11 | 1.3 | **Current state assessment** |  | 70d | 2009-07-20 | 2009-10-23 |  | 1070d |  |  |
| 12 | 1.3.1 | Customer analysis - desk research |  | 10d | 2009-07-20 | 2009-07-31 |  | 381d |  | start no earlier than 2009-07-20 |
| 13 | 1.3.2 | Customer analysis - quantative customer research |  | 15d | 2009-08-10 | 2009-08-28 |  | 361d |  | start no earlier than 2009-08-10 |
| 14 | 1.3.3 | Customer analysis - stakeholder interviews |  | 15d | 2009-08-31 | 2009-09-18 |  | 341d | 0d | start no earlier than 2009-08-31 |
| 15 | 1.3.4 | Customer analysis - analysis of findings (in briefing report) |  | 5d | 2009-09-21 | 2009-09-25 | 14 | 341d |  |  |
| 16 | 1.3.5 | Business process mapping - identifying key BPs |  | 2d | 2009-09-14 | 2009-09-15 |  | 349d |  | start no earlier than 2009-09-14 |
| 17 | 1.3.6 | Business process mapping - gathering existing BP docs |  | 8d | 2009-09-16 | 2009-09-25 |  | 316d | 0d | start no earlier than 2009-09-16 |
| 18 | 1.3.7 | Business process mapping - review of current BPs |  | 10d | 2009-09-28 | 2009-10-09 | 17 | 316d | 0d |  |
| 19 | 1.3.8 | Business process mapping - analysis for BPR oppportunities |  | 10d | 2009-10-12 | 2009-10-23 | 18 | 316d | 0d |  |
| 20 | 1.3.9 | IT maturity assessment - dev/agree assessment criteria |  | 3d | 2009-09-07 | 2009-09-09 |  | 341d | 0d | start no earlier than 2009-09-07 |
| 21 | 1.3.10 | IT maturity assessment - carry out assessment |  | 7d | 2009-09-10 | 2009-09-18 | 20 | 341d | 0d |  |
| 22 | 1.3.11 | IT maturity assessment - analysis of findings (in briefing report) |  | 5d | 2009-09-21 | 2009-09-25 | 21 | 341d |  |  |
| 23 | 1.4 | **Porfolio selection** |  | 25d | 2009-10-26 | 2009-11-27 |  | 1033d |  |  |
| 24 | 1.4.1 | Options appraisal |  | 10d | 2009-10-26 | 2009-11-06 |  | 284d | 0d | start no earlier than 2009-10-26 |
| 25 | 1.4.2 | Target strategies |  | 10d | 2009-11-09 | 2009-11-20 | 24 | 284d | 0d | start no earlier than 2009-08-17 |
| 26 | 1.4.3 | Gap analysis |  | 2d | 2009-11-23 | 2009-11-24 | 25 | 284d | 0d | start no earlier than 2009-08-24 |
| 27 | 1.4.4 | Revisit target strategies |  | 3d | 2009-11-25 | 2009-11-27 | 26 | 284d | 0d |  |

| ID | WBS | Task | Type | Duration | Start | Finish | Predecessors | Total slack | Free slack | Constraint |
| --- | --- | --- | --- | --- | --- | --- | --- | --- | --- | --- |
| 28 | 1.5 | **Strategy validation** |  | 50d | 2009-10-19 | 2009-12-25 |  | 980d |  |  |
| 29 | 1.5.1 | Transformation vision - develop draft |  | 5d | 2009-11-30 | 2009-12-04 | 27 | 284d | 0d |  |
| 30 | 1.5.2 | Transformation vision - validate with key stakeholders |  | 5d | 2009-12-07 | 2009-12-11 | 29 | 284d | 0d |  |
| 31 | 1.5.3 | Transformation vision - finalise and sign off | milestone | 2d | 2009-12-14 | 2009-12-15 | 30 | 284d |  |  |
| 32 | 1.5.4 | Strategic business case - develop draft |  | 20d | 2009-10-26 | 2009-11-20 |  | 261d | 10d | start no earlier than 2009-10-26 |
| 33 | 1.5.5 | Strategic business case - validate with key stakeholders |  | 5d | 2009-12-07 | 2009-12-11 | 32 | 251d | 0d | start no earlier than 2009-12-07 |
| 34 | 1.5.6 | Strategic business case - finalise and sign off | milestone | 5d | 2009-12-14 | 2009-12-18 | 33 | 251d | 0d | start no earlier than 2009-12-07 |
| 35 | 1.5.7 | Enterprise architecture - develop draft |  | 25d | 2009-10-19 | 2009-11-20 |  | 236d | 0d | start no earlier than 2009-10-19 |
| 36 | 1.5.8 | Enterprise architecture - validate with key stakeholders |  | 10d | 2009-11-23 | 2009-12-04 | 35 | 236d | 0d |  |
| 37 | 1.5.9 | Enterprise architecture - finalise and sign off | milestone | 10d | 2009-12-07 | 2009-12-18 | 36 | 236d | 0d |  |
| 38 | 1.5.10 | Transformation roadmap - develop draft |  | 25d | 2009-11-02 | 2009-12-04 |  | 249d | 0d | start no earlier than 2009-11-02 |
| 39 | 1.5.11 | Transformation roadmap - validate with key stakeholders |  | 10d | 2009-12-07 | 2009-12-18 | 38 | 249d | 0d |  |
| 40 | 1.5.12 | Transformation roadmap - finalise and sign off | milestone | 5d | 2009-12-21 | 2009-12-25 | 39 | 249d | 0d |  |
| 42 | 2 | **Business leadership** |  | 610d | 2010-01-04 | 2012-05-04 |  | 410d |  |  |
| 43 | 2.1 | **Governance** |  | 66d | 2010-01-04 | 2010-04-05 |  | 954d |  |  |
| 44 | 2.1.1 | Develop pan-government governance model |  | 10d | 2010-01-04 | 2010-01-15 |  | 256d | 0d | start no earlier than 2010-01-04 |
| 45 | 2.1.2 | Implement governance model (accountability/escalation/decision making responsibilities) | milestone | 10d | 2010-01-18 | 2010-01-29 | 44 | 246d | 0d | finish no earlier than 2009-10-23 |
| 46 | 2.1.3 | Introduce performance dashboards |  | 5d | 2010-02-01 | 2010-02-05 | 45 | 246d |  |  |
| 47 | 2.1.4 | Integrate programme with existing governance groups | milestone | 20d | 2010-01-25 | 2010-02-19 |  | 236d |  | start no earlier than 2010-01-25 |
| 48 | 2.1.5 | Establish central CIO function |  | 15d | 2010-02-01 | 2010-02-19 |  | 236d |  | start no earlier than 2010-02-01 |
| 49 | 2.1.6 | Assess effectiveness of governance model | milestone | 1d | 2010-04-05 | 2010-04-05 |  | 205d |  | start no earlier than 2010-04-05 |
| 50 | 2.2 | **Stakeholder engagement** |  | 146d | 2010-01-11 | 2010-08-02 |  | 869d |  |  |
| 51 | 2.2.1 | Develop internal comms plan |  | 10d | 2010-01-11 | 2010-01-22 |  | 256d |  | start no earlier than 2010-01-11 |
| 52 | 2.2.2 | Launch event - presenting transformation vision and roadmap | milestone | 1d | 2010-01-25 | 2010-01-25 | 40 | 250d | 0d | start no earlier than 2010-01-25 |
| 53 | 2.2.3 | Develop stakeholder FAQs database |  | 5d | 2010-01-26 | 2010-02-01 | 52 | 250d |  |  |
| 54 | 2.2.4 | Identify early adopter agencies |  | 5d | 2010-01-25 | 2010-01-29 |  | 131d | 0d | start no earlier than 2010-01-25 |
| 55 | 2.2.5 | Regular internal comms - quarterly | milestone | 1d | 2010-02-01 | 2010-02-01 |  | 250d |  | start no earlier than 2010-02-01 |
| 56 | 2.2.6 | Regular internal comms - quarterly | milestone | 1d | 2010-05-03 | 2010-05-03 |  | 185d |  | start no earlier than 2010-05-03 |
| 57 | 2.2.7 | Regular internal comms - quarterly | milestone | 1d | 2010-08-02 | 2010-08-02 |  | 120d |  | start no earlier than 2010-08-02 |

| ID | WBS | Task | Type | Duration | Start | Finish | Predecessors | Total slack | Free slack | Constraint |
| --- | --- | --- | --- | --- | --- | --- | --- | --- | --- | --- |
| 58 | 2.3 | **Risk management strategy** |  | 216d | 2010-02-08 | 2010-12-06 |  | 779d |  |  |
| 59 | 2.3.1 | Implement risk management strategy |  | 15d | 2010-02-08 | 2010-02-26 | 40 | 231d |  | start no earlier than 2010-02-08 |
| 60 | 2.3.2 | Assess effectiveness of risk management strategy | milestone | 1d | 2010-04-05 | 2010-04-05 |  | 205d |  | start no earlier than 2010-04-05 |
| 61 | 2.3.3 | Regular risk mitigation reports to board - quarterly | milestone | 1d | 2010-06-07 | 2010-06-07 |  | 160d |  | start no earlier than 2010-06-07 |
| 62 | 2.3.4 | Regular risk mitigation reports to board - quarterly | milestone | 1d | 2010-09-06 | 2010-09-06 |  | 95d |  | start no earlier than 2010-09-06 |
| 63 | 2.3.5 | Regular risk mitigation reports to board - quarterly | milestone | 1d | 2010-12-06 | 2010-12-06 |  | 30d |  | start no earlier than 2010-12-06 |
| 64 | 2.4 | **Policies and standards** |  | 120d | 2010-01-04 | 2010-06-18 |  | 865d |  |  |
| 65 | 2.4.1 | Review and baseline EA framework |  | 10d | 2010-01-04 | 2010-01-15 | 37 | 176d | 0d | start no earlier than 2010-01-04 |
| 66 | 2.4.2 | Develop detailed interoperability standards and policies |  | 35d | 2010-01-18 | 2010-03-05 | 65 | 176d | 0d |  |
| 67 | 2.4.3 | Develop standards related to ID management (message security, access etc) |  | 35d | 2010-01-18 | 2010-03-05 |  | 755d | 0d | start no earlier than 2010-01-18 |
| 68 | 2.4.4 | Roll-out plan for interoperability standards and policies |  | 20d | 2010-03-08 | 2010-04-02 | 67 | 825d | 10d | start no earlier than 2009-11-16 |
| 69 | 2.4.5 | Implement interoperability standards and policies |  | 30d | 2010-04-19 | 2010-05-28 | 68 | 815d |  | start no earlier than 2010-04-19 |
| 70 | 2.4.6 | Develop standards management process |  | 10d | 2010-04-26 | 2010-05-07 |  | 830d |  | start no earlier than 2010-04-26 |
| 71 | 2.4.7 | Refine standards and policies | milestone | 5d | 2010-06-14 | 2010-06-18 |  | 800d |  | start no earlier than 2010-06-14 |
| 72 | 2.5 | **Sourcing strategy** |  | 600d | 2010-01-18 | 2012-05-04 |  | 410d |  |  |
| 73 | 2.5.1 | Audit of current suppliers |  | 20d | 2010-01-18 | 2010-02-12 |  | 720d | 0d | start no earlier than 2010-01-18 |
| 74 | 2.5.2 | Effectiveness review - stakeholder input |  | 15d | 2010-02-15 | 2010-03-05 | 73 | 720d | 0d |  |
| 75 | 2.5.3 | Recommendations report |  | 5d | 2010-03-08 | 2010-03-12 | 74 | 720d | 0d |  |
| 76 | 2.5.4 | Implement recommendations |  | 60d | 2010-03-15 | 2010-06-04 | 75 | 720d | 0d |  |
| 77 | 2.5.5 | Supplier rationalisation |  | 200d | 2010-06-07 | 2011-03-11 | 76 | 410d | 0d |  |
| 78 | 2.5.6 | Ongoing supplier management (standardised procedures) |  | 300d | 2011-03-14 | 2012-05-04 | 77 | 410d |  | finish no earlier than 2010-12-31 |
| 79 | 2.6 | **Benefit realisation plan** |  | 216d | 2010-01-04 | 2010-11-01 |  | 804d |  |  |
| 80 | 2.6.1 | Develop programme benefits realisation plan |  | 30d | 2010-01-04 | 2010-02-12 | 34 | 890d |  | start no earlier than 2010-01-04 |
| 81 | 2.6.2 | Launch benefits realisation plan to stakeholders | milestone | 1d | 2010-03-01 | 2010-03-01 |  | 879d |  | start no earlier than 2010-03-01 |
| 82 | 2.6.3 | Empower "benefit owners" for all CSP workstreams |  | 15d | 2010-03-01 | 2010-03-19 |  | 835d | 0d | start no earlier than 2010-03-01 |
| 83 | 2.6.4 | Develop agency level benefit realisation measures |  | 30d | 2010-03-22 | 2010-04-30 | 82 | 835d |  |  |
| 84 | 2.6.5 | Implement agency level benefit realisation measures | milestone | 20d | 2010-03-22 | 2010-04-16 |  | 845d |  | start no earlier than 2010-03-22 |
| 85 | 2.6.6 | Checkpoints with senior governance group - quarterly | milestone | 1d | 2010-05-03 | 2010-05-03 |  | 834d |  | start no earlier than 2010-05-03 |
| 86 | 2.6.7 | Checkpoints with senior governance group - quarterly | milestone | 1d | 2010-08-02 | 2010-08-02 |  | 769d |  | start no earlier than 2010-08-02 |
| 87 | 2.6.8 | Checkpoints with senior governance group - quarterly | milestone | 1d | 2010-11-01 | 2010-11-01 |  | 704d |  | start no earlier than 2010-11-01 |

| ID | WBS | Task | Type | Duration | Start | Finish | Predecessors | Total slack | Free slack | Constraint |
| --- | --- | --- | --- | --- | --- | --- | --- | --- | --- | --- |
| 89 | 3 | **People and processes** |  | 450d | 2010-01-18 | 2011-10-07 |  | 560d |  |  |
| 90 | 3.1 | **Capability review** |  | 101d | 2010-02-01 | 2010-06-21 |  | 899d |  |  |
| 91 | 3.1.1 | Existing skills assessment |  | 30d | 2010-02-01 | 2010-03-12 |  | 855d | 0d | start no earlier than 2010-02-01 |
| 92 | 3.1.2 | Develop specifications for required resources |  | 10d | 2010-03-01 | 2010-03-12 |  | 855d | 0d | start no earlier than 2010-03-01 |
| 93 | 3.1.3 | Skill gap analysis (current to future requirement) |  | 15d | 2010-03-15 | 2010-04-02 | 91, 92 | 855d |  |  |
| 94 | 3.1.4 | Internal resource development plans |  | 5d | 2010-04-05 | 2010-04-09 |  | 850d |  | start no earlier than 2010-04-05 |
| 95 | 3.1.5 | External resource recruitment plans |  | 15d | 2010-04-12 | 2010-04-30 |  | 835d |  | start no earlier than 2010-04-12 |
| 96 | 3.1.6 | Checkpoint - team effectiveness review | milestone | 1d | 2010-05-31 | 2010-05-31 |  | 799d | 0d | start no earlier than 2010-05-31 |
| 97 | 3.1.7 | Implement recommended improvements |  | 15d | 2010-06-01 | 2010-06-21 | 96 | 799d |  |  |
| 98 | 3.2 | **Training and support** |  | 180d | 2010-04-12 | 2010-12-17 |  | 770d |  |  |
| 99 | 3.2.1 | Ongoing training and support plans |  | 180d | 2010-04-12 | 2010-12-17 |  | 670d |  | start no earlier than 2010-04-12 |
| 100 | 3.3 | **Change management** |  | 116d | 2010-02-15 | 2010-07-26 |  | 874d |  |  |
| 101 | 3.3.1 | Develop change management strategy |  | 15d | 2010-02-15 | 2010-03-05 | 40 | 835d | 0d | start no earlier than 2010-02-15 |
| 102 | 3.3.2 | Define role of change agent |  | 5d | 2010-03-08 | 2010-03-12 | 101 | 835d | 0d |  |
| 103 | 3.3.3 | Establish change teams |  | 15d | 2010-03-15 | 2010-04-02 | 102 | 835d | 0d |  |
| 104 | 3.3.4 | Develop change management plans |  | 20d | 2010-04-05 | 2010-04-30 | 103 | 835d |  |  |
| 105 | 3.3.5 | Implement change management plans |  | 30d | 2010-05-03 | 2010-06-11 |  | 805d |  | start no earlier than 2010-05-03 |
| 106 | 3.3.6 | Assess effectiveness of change management | milestone | 1d | 2010-07-05 | 2010-07-05 |  | 774d | 0d | start no earlier than 2010-07-05 |
| 107 | 3.3.7 | Implement recommended improvements |  | 15d | 2010-07-06 | 2010-07-26 | 106 | 774d |  |  |
| 108 | 3.4 | **Business process reengineering** |  | 245d | 2010-01-18 | 2010-12-24 |  | 765d |  |  |
| 109 | 3.4.1 | Prioritise customer facing services for BRP (low to high risk) |  | 15d | 2010-01-18 | 2010-02-05 | 19 | 895d |  | start no earlier than 2010-01-18 |
| 110 | 3.4.2 | Prioritise internal shared services for BRP (low to high risk) |  | 10d | 2010-02-08 | 2010-02-19 |  | 885d |  | start no earlier than 2010-02-08 |
| 111 | 3.4.3 | Develop BPR plan (aligned to deployment schedule) |  | 20d | 2010-02-22 | 2010-03-19 |  | 805d | 0d | start no earlier than 2010-02-22 |
| 112 | 3.4.4 | Complete 1st tranche of BPR |  | 60d | 2010-03-22 | 2010-06-11 | 111 | 805d |  |  |
| 113 | 3.4.5 | Complete 2nd tranche of BPR |  | 60d | 2010-07-05 | 2010-09-24 |  | 730d |  | start no earlier than 2010-07-05 |
| 114 | 3.4.6 | Complete 3rd tranche of BPR |  | 60d | 2010-10-04 | 2010-12-24 |  | 665d |  | start no earlier than 2010-10-04 |

| ID | WBS | Task | Type | Duration | Start | Finish | Predecessors | Total slack | Free slack | Constraint |
| --- | --- | --- | --- | --- | --- | --- | --- | --- | --- | --- |
| 115 | 3.5 | **Channel management** |  | 440d | 2010-02-01 | 2011-10-07 |  | 560d |  |  |
| 116 | 3.5.1 | Develop channel management strategy |  | 60d | 2010-02-01 | 2010-04-23 |  | 560d | 0d | start no earlier than 2010-02-01 |
| 117 | 3.5.2 | Deliver channel management strategy (channel launches) |  | 200d | 2010-04-26 | 2011-01-28 | 116 | 560d | 0d |  |
| 118 | 3.5.3 | Assess effectiveness of channel shift |  | 60d | 2011-01-31 | 2011-04-22 | 117 | 560d | 0d |  |
| 119 | 3.5.4 | Implement recommended improvements |  | 120d | 2011-04-25 | 2011-10-07 | 118 | 560d |  |  |
| 120 | 3.6 | **One-stop delivery service** |  | 371d | 2010-02-01 | 2011-07-04 |  | 629d |  |  |
| 121 | 3.6.1 | Identify initial franchise groups (early adopter group) |  | 10d | 2010-02-01 | 2010-02-12 | 54 | 990d |  |  |
| 122 | 3.6.2 | Develop and agree business model for early adopter group |  | 15d | 2010-02-15 | 2010-03-05 |  | 975d |  | start no earlier than 2010-02-15 |
| 123 | 3.6.3 | Identify low risk services for deployment for 1st release of portal |  | 15d | 2010-03-01 | 2010-03-19 |  | 965d |  | start no earlier than 2010-03-01 |
| 124 | 3.6.4 | Work with early adopter group to launch first wave of service transformations |  | 120d | 2010-03-22 | 2010-09-03 | 54 | 844d | 10d | start no earlier than 2010-03-22 |
| 125 | 3.6.5 | Launch 1st release of web delivery channel | milestone | 1d | 2010-09-20 | 2010-09-20 | 145, 124 | 834d |  | start no earlier than 2010-04-05 |
| 126 | 3.6.6 | Refine operational model for future roll-outs |  | 20d | 2010-09-13 | 2010-10-08 |  | 820d |  | start no earlier than 2010-09-13 |
| 127 | 3.6.7 | Work with second tranche adopter group - 2nd release |  | 150d | 2010-08-02 | 2011-02-25 |  | 719d | 0d | start no earlier than 2010-08-02 |
| 128 | 3.6.8 | Launch 2nd release of web delivery channel | milestone | 1d | 2011-02-28 | 2011-02-28 | 127 | 719d |  | start no earlier than 2010-09-06 |
| 129 | 3.6.9 | Work with third tranche adopter group - 3rd release |  | 150d | 2010-12-06 | 2011-07-01 |  | 629d | 0d | start no earlier than 2010-12-06 |
| 130 | 3.6.10 | Launch 3rd release of web delivery channel | milestone | 1d | 2011-07-04 | 2011-07-04 | 129 | 629d |  | start no earlier than 2011-01-17 |
| 131 | 3.6.11 | Review of existing contact centre operations |  | 30d | 2010-04-05 | 2010-05-14 |  | 835d | 0d | start no earlier than 2010-04-05 |
| 132 | 3.6.12 | Contact centre service redesign (alignment with web delivery channel) |  | 90d | 2010-05-17 | 2010-09-17 | 131, 116 | 835d |  |  |
| 133 | 3.6.13 | Launch of new contact centre operations | milestone | 1d | 2010-11-01 | 2010-11-01 | 149 | 804d |  | start no earlier than 2010-11-01 |
| 134 | 3.6.14 | Assess effectiveness of contact centre operations |  | 5d | 2010-12-06 | 2010-12-10 |  | 755d | 0d | start no earlier than 2010-12-06 |
| 135 | 3.6.15 | Implement recommended improvements |  | 20d | 2010-12-13 | 2011-01-07 | 134 | 755d |  |  |
| 136 | 3.6.16 | Review of existing walk-in centre operations |  | 30d | 2010-05-03 | 2010-06-11 |  | 815d | 0d | start no earlier than 2010-05-03 |
| 137 | 3.6.17 | Walk-in service redesign (alignment with web delivery channel) |  | 90d | 2010-06-14 | 2010-10-15 | 136, 116 | 815d |  | start no earlier than 2010-04-12 |
| 138 | 3.6.18 | Launch of new walk-in centre operations | milestone | 1d | 2010-12-06 | 2010-12-06 | 150 | 779d |  | start no earlier than 2010-12-06 |
| 139 | 3.6.19 | Assess effectiveness of walk-in centre operations |  | 5d | 2011-02-07 | 2011-02-11 |  | 710d | 0d | start no earlier than 2011-02-07 |
| 140 | 3.6.20 | Implement recommended improvements |  | 20d | 2011-02-14 | 2011-03-11 | 139 | 710d |  | start no earlier than 2010-12-13 |

| ID | WBS | Task | Duration | Start | Finish | Predecessors | Total slack | Free slack | Constraint |
| --- | --- | --- | --- | --- | --- | --- | --- | --- | --- |
| 141 | 3.7 | **Marketing** | 237d | 2010-02-15 | 2011-01-11 |  | 753d |  |  |
| 142 | 3.7.1 | Develop external communications and marketing strategy | 20d | 2010-02-15 | 2010-03-12 |  | 970d |  | start no earlier than 2010-02-15 |
| 143 | 3.7.2 | Assess most appropriate media channels for marketing | 2d | 2010-03-01 | 2010-03-02 |  | 973d | 0d | start no earlier than 2010-03-01 |
| 144 | 3.7.3 | Carry out programme awareness events with relevant media reps | 5d | 2010-03-03 | 2010-03-09 | 143 | 973d |  |  |
| 145 | 3.7.4 | Prepare media communications for web channel initial launch | 20d | 2010-08-23 | 2010-09-17 |  | 834d | 0d | start no earlier than 2010-08-23 |
| 146 | 3.7.5 | Develop longer term communications plan to enhance take-up | 20d | 2010-10-04 | 2010-10-29 |  | 805d |  | start no earlier than 2010-10-04 |
| 147 | 3.7.6 | Develop and implement customer satisfaction surveys | 30d | 2010-10-04 | 2010-11-12 |  | 795d |  | start no earlier than 2010-10-04 |
| 148 | 3.7.7 | Implement recommended improvements | 30d | 2010-12-01 | 2011-01-11 |  | 753d |  | start no earlier than 2010-12-01 |
| 149 | 3.7.8 | Media communications for contact centre launch | 10d | 2010-10-11 | 2010-10-22 |  | 809d | 5d | start no earlier than 2010-10-11 |
| 150 | 3.7.9 | Media communications for walk-in centre launch | 10d | 2010-11-08 | 2010-11-19 |  | 789d | 10d | start no earlier than 2010-11-08 |
| 152 | 4 | **Solutions** | 879d | 2010-03-02 | 2013-07-12 |  | 100d |  |  |
| 153 | 4.1 | **Application enhancement and rationalisation** | 804d | 2010-03-02 | 2013-03-29 |  | 175d |  |  |
| 154 | 4.1.1 | Audit of current applications across government | 60d | 2010-03-02 | 2010-05-24 |  | 839d | 0d | start no earlier than 2010-03-02 |
| 155 | 4.1.2 | Analysis of findings (in report) | 20d | 2010-05-25 | 2010-06-21 | 154 | 839d | 9d |  |
| 156 | 4.1.3 | Identify exemplar government applications | 20d | 2010-06-28 | 2010-07-23 |  | 875d |  | start no earlier than 2010-06-28 |
| 157 | 4.1.4 | Identify and deliver quick win solutions | 40d | 2010-07-05 | 2010-08-27 |  | 850d |  | start no earlier than 2010-07-05 |
| 158 | 4.1.5 | Develop migration strategies to exemplar applications | 60d | 2010-07-05 | 2010-09-24 | 155 | 830d |  | start no earlier than 2010-07-05 |
| 159 | 4.1.6 | Migration to exemplar applications | 300d | 2010-10-04 | 2011-11-25 |  | 525d |  | start no earlier than 2010-10-04 |
| 160 | 4.1.7 | Decommission legacy apps | 500d | 2011-05-02 | 2013-03-29 |  | 175d |  | start no earlier than 2011-05-02 |
| 161 | 4.1.8 | Licencing rationalisation | 200d | 2011-06-06 | 2012-03-09 |  | 450d |  | start no earlier than 2011-06-06 |
| 162 | 4.2 | **Identity management** | 875d | 2010-03-08 | 2013-07-12 |  | 100d |  |  |
| 163 | 4.2.1 | Develop pan-government ID management strategy | 120d | 2010-03-08 | 2010-08-20 | 67 | 855d |  | start no earlier than 2010-03-01 |
| 164 | 4.2.2 | Audit of current ID management solutions | 60d | 2010-05-03 | 2010-07-23 |  | 875d |  | start no earlier than 2010-05-03 |
| 165 | 4.2.3 | Assessment of services by authentication level | 30d | 2010-07-26 | 2010-09-03 |  | 845d |  | start no earlier than 2010-07-26 |
| 166 | 4.2.4 | Deliver initial pan government identity solution | 200d | 2010-09-06 | 2011-06-10 |  | 645d |  | start no earlier than 2010-09-06 |
| 167 | 4.2.5 | Scope requirements for strategic ID management solution | 120d | 2011-08-01 | 2012-01-13 |  | 490d |  | start no earlier than 2011-08-01 |
| 168 | 4.2.6 | Deliver Long term pan government identity solution | 400d | 2012-01-02 | 2013-07-12 |  | 100d |  | start no earlier than 2012-01-02 |

| ID | WBS | Task | Duration | Start | Finish | Predecessors | Total slack | Free slack | Constraint |
| --- | --- | --- | --- | --- | --- | --- | --- | --- | --- |
| 170 | 5 | **Technology platform** | 890d | 2010-07-05 | 2013-11-29 |  | 0d |  |  |
| 171 | 5.1 | **Technology enhancement and rationalisation** | 740d | 2010-07-05 | 2013-05-03 |  | 150d |  |  |
| 172 | 5.1.1 | Audit of current technology platforms | 90d | 2010-07-05 | 2010-11-05 |  | 770d | 0d | start no earlier than 2010-07-05 |
| 173 | 5.1.2 | Analysis of findings (in report) | 30d | 2010-11-08 | 2010-12-17 | 172 | 770d |  |  |
| 174 | 5.1.3 | Develop strategy for shared infrastructure | 60d | 2010-11-29 | 2011-02-18 |  | 725d |  | start no earlier than 2010-11-29 |
| 175 | 5.1.4 | Identify exemplar government technologies | 30d | 2011-01-03 | 2011-02-11 |  | 730d |  | start no earlier than 2011-01-03 |
| 176 | 5.1.5 | Migration strategy (technology platforms) | 90d | 2010-11-01 | 2011-03-04 |  | 515d | 0d | start no earlier than 2010-11-01 |
| 177 | 5.1.6 | Implement migration strategy | 200d | 2011-03-07 | 2011-12-09 | 176 | 515d |  |  |
| 178 | 5.1.7 | Future technology requirements | 120d | 2011-02-01 | 2011-07-18 |  | 619d |  | start no earlier than 2011-02-01 |
| 179 | 5.1.8 | Decommission legacy systems | 500d | 2011-06-06 | 2013-05-03 |  | 150d |  | start no earlier than 2011-06-06 |
| 180 | 5.2 | **Datacentre enhancement and rationalisation** | 890d | 2010-07-05 | 2013-11-29 |  | 0d |  |  |
| 181 | 5.2.1 | Audit of current government datacentres | 60d | 2010-07-05 | 2010-09-24 |  | 830d |  | start no earlier than 2010-07-05 |
| 182 | 5.2.2 | Develop strategy for shared datacentres | 60d | 2010-11-29 | 2011-02-18 |  | 725d |  | start no earlier than 2010-11-29 |
| 183 | 5.2.3 | Datacentre rationalisation | 300d | 2011-04-04 | 2012-05-25 |  | 395d |  | start no earlier than 2011-04-04 |
| 184 | 5.2.4 | Datacentre virtualisation | 500d | 2012-01-02 | 2013-11-29 |  | 0d |  | start no earlier than 2012-01-02 |
